# Residential Construction

Schedule from MS Project, 2008-08-21 to 2009-07-31, A marks actual dates.

## Calendars

- Standard: Mon-Fri 08:00-12:00, 13:00-17:00; Sat-Sun off.

## Resources

| Resource |
| --- |
| Concrete contractor |
| Finish carpentry contractor |
| Fencing contractor |
| Masonry contractor |
| General contractor |
| Architect |
| Owner |
| Mortgage lender |
| Inspector |
| Electric company |
| Site excavation contractor |
| Electric contractor |
| Plumbing contractor |
| Framing contractor |
| Roofing contractor |
| Heating and AC contractor |
| Insulation contractor |
| Drywall contractor |
| Painting contractor |
| Flooring contractor |
| Appliance contractor |
| Landscape contractor |
| Maid service |
| Finishing contractor |

## Schedule

| ID | WBS | Task | Type | Duration | Start | Finish | Predecessors | Remaining | Total slack | Free slack | Constraint | Resources | Work | Actual work |
| --- | --- | --- | --- | --- | --- | --- | --- | --- | --- | --- | --- | --- | --- | --- |
| 1 | 1 | **Timber Frame Home Construction Schedule** |  | 247d? | 2008-08-21 A | 2009-07-31 |  | 246.17d? | 0d |  |  |  | 1678.88h | 8h |
| 2 | 1.1 | **General Conditions** |  | 17d | 2008-08-21 | 2008-09-15 |  |  | 230d |  |  |  | 170.88h |  |
| 3 | 1.1.1 | Finalize plans and develop estimate with owner, architect |  | 14d | 2008-08-21 | 2008-09-09 |  |  | 251d |  | start no earlier than 2008-08-21 | General contractor [50%]; Architect [50%]; Owner [12%]; Mortgage lender [12%] | 138.88h |  |
| 4 | 1.1.2 | Sign contract and notice to proceed |  | 1d | 2008-09-11 | 2008-09-11 |  |  | 249d |  | start no earlier than 2008-09-11 | General contractor; Architect; Owner; Mortgage lender | 32h |  |
| 5 | 1.1.3 | **Apply for Permits** |  | 0d | 2008-09-15 | 2008-09-15 |  |  | 230d |  |  |  |  |  |
| 6 | 1.1.3.1 | Secure Building Permit | milestone | 0d | 2008-09-15 | 2008-09-15 |  |  | 248d |  |  | General contractor |  |  |
| 7 | 1.1.3.2 | Secure miscellaneous permits | milestone | 0d | 2008-09-15 | 2008-09-15 |  |  | 214d |  |  | General contractor |  |  |
| 8 | 1.2 | **Site Work** |  | 13d | 2008-09-15 | 2008-10-01 |  |  | 144.5d |  |  |  | 80h |  |
| 9 | 1.2.1 | Clear and build road |  | 5d | 2008-09-15 | 2008-09-19 |  |  | 140.5d | 0d | start no earlier than 2008-09-15 |  |  |  |
| 10 | 1.2.2 | Clear and grub lot |  | 5d | 2008-09-22 | 2008-09-26 | 9 |  | 140.5d | 0d | start no earlier than 2008-09-19 | Site excavation contractor | 40h |  |
| 11 | 1.2.3 | Install temporary power service |  | 1d | 2008-09-29 | 2008-09-29 | 10 |  | 201d | 0d | start no earlier than 2008-09-23 | Electric company | 8h |  |
| 12 | 1.2.4 | Install underground utilities |  | 2d | 2008-09-30 | 2008-10-01 | 11 |  | 201d |  | start no earlier than 2008-09-23 | Electric contractor; Plumbing contractor | 32h |  |
| 13 | 1.3 | **Foundation** |  | 26.5d | 2008-10-01 | 2008-11-06 |  |  | 142.5d |  |  |  | 96h |  |
| 14 | 1.3.1 | Excavate for foundations |  | 5d | 2008-10-01 | 2008-10-07 | 10 |  | 142.5d | 1d | start no earlier than 2008-10-01 | Site excavation contractor | 40h |  |
| 15 | 1.3.2 | Prepare and Pour Footers |  | 4d | 2008-10-09 | 2008-10-14 | 14 |  | 141.5d | 3d | start no earlier than 2008-10-09 |  |  |  |
| 16 | 1.3.3 | Pour Concrete Walls |  | 5d | 2008-10-20 | 2008-10-24 | 15 |  | 138.5d | 3d | start no earlier than 2008-10-20 | Concrete contractor | 40h |  |
| 17 | 1.3.4 | Pour Slab/Piers |  | 3.5d | 2008-10-30 | 2008-11-04 | 16 |  | 135.5d | 0d | start no earlier than 2008-10-30 |  |  |  |
| 18 | 1.3.5 | Waterproof Founation |  | 2d | 2008-11-04 | 2008-11-06 | 17 |  | 135.5d | 0d |  | Concrete contractor | 16h |  |
| 19 | 1.3.6 | Bank Draw | milestone | 0d | 2008-11-06 | 2008-11-06 |  |  | 192d |  | start no earlier than 2008-11-06 |  |  |  |
| 20 | 1.4 | **Conventional Framing** |  | 58.5d | 2008-11-06 | 2009-01-27 |  |  | 133d |  |  |  | 128h |  |
| 21 | 1.4.1 | **Floor System** |  | 8d | 2008-11-14 | 2008-11-26 |  |  | 133d |  |  |  | 64h |  |
| 22 | 1.4.1.1 | Install Floor Trusses |  | 5d | 2008-11-14 | 2008-11-20 | 27 |  | 133d | 0d | start no earlier than 2008-11-14 | Framing contractor | 40h |  |
| 23 | 1.4.1.2 | Lay floor decking |  | 2d | 2008-11-21 | 2008-11-24 | 22 |  | 133d | 0d |  | Framing contractor | 16h |  |
| 24 | 1.4.1.3 | Complete Floor Framing |  | 1d | 2008-11-25 | 2008-11-25 | 23 |  | 133d | 0d |  | Framing contractor | 8h |  |
| 25 | 1.4.1.4 | Bank Draw | milestone | 0d | 2008-11-26 | 2008-11-26 |  |  | 178d |  | start no earlier than 2008-11-26 |  |  |  |

| ID | WBS | Task | Type | Duration | Start | Finish | Predecessors | Total slack | Free slack | Constraint | Resources | Work |
| --- | --- | --- | --- | --- | --- | --- | --- | --- | --- | --- | --- | --- |
| 26 | 1.4.2 | **Rough Framing** |  | 58.5d | 2008-11-06 | 2009-01-27 |  | 133d |  |  |  | 64h |
| 27 | 1.4.2.1 | Install 2x Ground Interior/Exterior Walls |  | 3d | 2008-11-06 | 2008-11-11 | 18 | 135.5d | 2.5d | start no earlier than 2008-11-02 |  |  |
| 28 | 1.4.2.2 | Install 2x 1st Floor Exterior Walls |  | 3d | 2009-01-15 | 2009-01-19 | 38 | 133d | 0d | start no earlier than 2008-12-29 |  |  |
| 29 | 1.4.2.3 | Install 2x 1st Floor Interior Walls |  | 3d | 2009-01-20 | 2009-01-22 | 28 | 133d | 0d |  |  |  |
| 30 | 1.4.2.4 | Hang 1st floor/Ground exterior doors |  | 1d | 2009-01-23 | 2009-01-23 | 29 | 133d | 0d |  | Framing contractor | 8h |
| 31 | 1.4.2.5 | Install Ground Floor Windows |  | 1d | 2009-01-26 | 2009-01-26 | 30 | 133d | 0d |  | Framing contractor | 8h |
| 32 | 1.4.2.6 | Install 1st floor windows |  | 1d | 2009-01-27 | 2009-01-27 | 31 | 133d |  |  | Framing contractor | 8h |
| 33 | 1.4.2.7 | Install felt, flashing and shingles |  | 5d | 2009-01-21 | 2009-01-27 |  | 133d |  | start no earlier than 2009-01-21 | Roofing contractor | 40h |
| 34 | 1.5 | **Timber Frame Install** |  | 36d | 2008-11-26 | 2009-01-14 |  | 133d |  |  |  | 8h |
| 35 | 1.5.1 | Timber Frame Install |  | 21d | 2008-11-26 | 2008-12-24 | 24 | 133d | 0d | start no earlier than 2008-11-24 |  |  |
| 36 | 1.5.2 | T&G Decking Intall |  | 4d | 2008-12-25 | 2008-12-30 | 35 | 133d | 0d | start no earlier than 2008-11-30 |  |  |
| 37 | 1.5.3 | Install Underlayment |  | 1d | 2008-12-31 | 2008-12-31 | 36 | 133d | 0d | start no earlier than 2008-11-13 | Framing contractor | 8h |
| 38 | 1.5.4 | Install Roof SIPS |  | 10d | 2009-01-01 | 2009-01-14 | 37 | 133d | 0d |  |  |  |
| 39 | 1.5.5 | Bank Draw | milestone | 0d | 2009-01-14 | 2009-01-14 |  | 142d |  | finish no earlier than 2009-01-14 |  |  |
| 40 | 1.6 | **Exterior Finishes** |  | 40d | 2009-02-06 | 2009-04-02 |  | 86d |  |  |  | 288h |
| 41 | 1.6.1 | Complete exterior stone |  | 16d | 2009-02-06 | 2009-02-27 |  | 86d | 0d | start no earlier than 2009-02-06 | Masonry contractor | 128h |
| 42 | 1.6.2 | Complete Deck/Exterior railings |  | 4d | 2009-03-02 | 2009-03-05 | 41 | 86d | 0d | start no earlier than 2009-02-22 |  |  |
| 43 | 1.6.3 | Complete exterior siding |  | 20d | 2009-03-06 | 2009-04-02 | 42 | 86d |  |  | Framing contractor | 160h |
| 44 | 1.7 | **Utility Rough-In** |  | 204d? | 2008-10-21 | 2009-07-31 |  | 0d |  |  |  | 144h |
| 45 | 1.7.1 | Rough-in under slab plumbing |  | 5d | 2008-10-21 | 2008-10-27 |  | 199d |  | start no earlier than 2008-10-21 | Plumbing contractor | 40h |
| 46 | 1.7.2 | Rough-in HVAC |  | 6d | 2009-02-06 | 2009-02-13 |  | 0d |  | start no earlier than 2009-02-06 | Heating and AC contractor | 48h |
| 47 | 1.7.3 | Rough-in Plumbing |  | 12d? | 2009-02-16 | 2009-07-31 | 46 | 0d |  |  |  |  |
| 48 | 1.7.4 | Rough-in electrical |  | 5d | 2009-02-23 | 2009-02-27 |  | 104d | 0d | start no earlier than 2009-02-22 | Electric contractor | 40h |
| 49 | 1.7.5 | Rough-in communication - phone, cable, computer, alarm |  | 2d | 2009-03-02 | 2009-03-03 | 48 | 104d | 10d |  | Electric contractor | 16h |
| 50 | 1.7.6 | Bank Draw | milestone | 0d | 2009-03-10 | 2009-03-10 | 49 | 104d |  | start no earlier than 2009-03-10 |  |  |

| ID | WBS | Task | Duration | Start | Finish | Predecessors | Complete | Remaining | Total slack | Free slack | Constraint | Resources | Work | Actual work |
| --- | --- | --- | --- | --- | --- | --- | --- | --- | --- | --- | --- | --- | --- | --- |
| 51 | 1.8 | **Interior Finishes** | 82d? | 2009-03-18 A | 2009-07-09 |  | 1% | 81.3d? | 16d |  |  |  | 764h | 8h |
| 52 | 1.8.1 | **Insulation** | 4d | 2009-03-18 | 2009-03-23 |  |  |  | 94d |  |  |  | 32h |  |
| 53 | 1.8.1.1 | Place wall insulation - 1st floor | 2d | 2009-03-18 | 2009-03-19 | 49 |  |  | 94d | 0d | start no earlier than 2009-03-18 | Insulation contractor | 16h |  |
| 54 | 1.8.1.2 | Place wall insulation - ground floor | 1d | 2009-03-20 | 2009-03-20 | 53 |  |  | 94d | 0d |  | Insulation contractor | 8h |  |
| 55 | 1.8.1.3 | Place ceiling insulation ground floor | 1d | 2009-03-23 | 2009-03-23 | 54 |  |  | 94d |  |  | Insulation contractor | 8h |  |
| 56 | 1.8.2 | **Flooring** | 7d | 2009-04-13 A | 2009-04-21 |  | 10% | 6.3d | 73d |  |  |  | 40h | 8h |
| 57 | 1.8.2.1 | Install Interior Flooring | 5d | 2009-04-13 | 2009-04-17 |  |  |  | 75d |  | start no earlier than 2009-04-11 |  |  |  |
| 58 | 1.8.2.2 | Tile entry, kitchen and baths | 5d | 2009-04-15 A | 2009-04-21 |  | 20% | 4d | 73d |  |  | Flooring contractor | 40h | 8h |
| 59 | 1.8.3 | **T&G** | 14d | 2009-04-03 | 2009-04-22 |  |  |  | 72d |  |  |  | 112h |  |
| 60 | 1.8.3.1 | Install T&G - 1st floor walls | 5d | 2009-04-03 | 2009-04-09 |  |  |  | 72d | 0d | start no earlier than 2009-04-03 | Finishing contractor | 40h |  |
| 61 | 1.8.3.2 | Install drywall - 1st floor overhead | 2d | 2009-04-10 | 2009-04-13 | 60 |  |  | 72d | 0d |  | Framing contractor | 16h |  |
| 62 | 1.8.3.3 | Install T&G ground floor walls | 5d | 2009-04-14 | 2009-04-20 | 61 |  |  | 72d | 0d |  | Framing contractor | 40h |  |
| 63 | 1.8.3.4 | Install drywall ground floor overhead | 2d | 2009-04-21 | 2009-04-22 | 62 |  |  | 72d |  |  | Framing contractor | 16h |  |
| 64 | 1.8.4 | **Paint** | 17d? | 2009-04-20 | 2009-05-12 |  |  |  | 58d |  |  |  | 172h |  |
| 65 | 1.8.4.1 | Interior 1st Floor | 10d | 2009-04-20 | 2009-05-01 |  |  |  | 65d |  | start no earlier than 2009-04-19 | Painting contractor | 80h |  |
| 66 | 1.8.4.2 | Interior Ground Floor | 11.5d? | 2009-04-20 | 2009-05-05 |  |  |  | 63.5d |  | start no earlier than 2009-04-19 | Painting contractor | 92h |  |
| 67 | 1.8.4.3 | Exterior | 12d? | 2009-04-27 | 2009-05-12 |  |  |  | 58d |  | start no earlier than 2009-04-27 |  |  |  |
| 68 | 1.8.5 | **Cabinets** | 21d | 2009-05-05 | 2009-06-02 |  |  |  | 43d |  |  |  | 168h |  |
| 69 | 1.8.5.1 | Install 1st floor - kitchen cabinets | 4d | 2009-05-05 | 2009-05-08 |  |  |  | 43d | 0d | start no earlier than 2009-05-05 | Finish carpentry contractor | 32h |  |
| 70 | 1.8.5.2 | Install - master bath and guest cabinets | 3d | 2009-05-11 | 2009-05-13 | 69 |  |  | 43d | 0d |  | Finish carpentry contractor | 24h |  |
| 71 | 1.8.5.3 | Install trim | 14d | 2009-05-14 | 2009-06-02 | 70 |  |  | 43d |  |  | Finish carpentry contractor | 112h |  |
| 72 | 1.8.6 | **Finish HVAC** | 3d | 2009-05-21 | 2009-05-25 |  |  |  | 49d |  |  |  | 24h |  |
| 73 | 1.8.6.1 | Complete 1st floor - zone 1 HVAC | 1d | 2009-05-21 | 2009-05-21 |  |  |  | 49d | 0d | start no earlier than 2009-05-21 | Heating and AC contractor | 8h |  |
| 74 | 1.8.6.2 | Complete 2nd floor - zone 2 HVAC | 1d | 2009-05-22 | 2009-05-22 | 73 |  |  | 49d | 0d |  | Heating and AC contractor | 8h |  |
| 75 | 1.8.6.3 | Conduct HVAC inspection | 1d | 2009-05-25 | 2009-05-25 | 74 |  |  | 49d |  |  | Inspector | 8h |  |

| ID | WBS | Task | Duration | Start | Finish | Predecessors | Total slack | Free slack | Constraint | Resources | Work |
| --- | --- | --- | --- | --- | --- | --- | --- | --- | --- | --- | --- |
| 76 | 1.8.7 | **Finish Plumbing** | 9d | 2009-05-29 | 2009-06-10 |  | 37d |  |  |  | 72h |
| 77 | 1.8.7.1 | Complete 1st floor - kitchen plumbing | 4d | 2009-05-29 | 2009-06-03 |  | 37d | 0d | start no earlier than 2009-05-29 | Plumbing contractor | 32h |
| 78 | 1.8.7.2 | Complete 1st floor - master bath and guest plumbing | 3d | 2009-06-04 | 2009-06-08 | 77 | 37d | 0d |  | Plumbing contractor | 24h |
| 79 | 1.8.7.3 | Complete 2nd floor - hall bath and private bath plumbing | 2d | 2009-06-09 | 2009-06-10 | 78 | 37d |  |  | Plumbing contractor | 16h |
| 80 | 1.8.8 | **Finish Electrical** | 9d | 2009-06-08 | 2009-06-18 |  | 31d |  |  |  | 56h |
| 81 | 1.8.8.1 | Complete 1st floor circuits to service panel | 2d | 2009-06-08 | 2009-06-09 |  | 31d | 0d | start no earlier than 2009-06-06 | Electric contractor | 16h |
| 82 | 1.8.8.2 | Complete Ground Floor circuits to service panel | 2d | 2009-06-10 | 2009-06-11 | 81 | 31d | 0d |  | Electric contractor | 16h |
| 83 | 1.8.8.3 | Install Electrical Fixtures | 5d | 2009-06-12 | 2009-06-18 | 82 | 31d |  |  |  |  |
| 84 | 1.8.8.4 | Install appliances | 1d | 2009-06-15 | 2009-06-15 |  | 34d |  | start no earlier than 2009-06-14 | Appliance contractor | 8h |
| 85 | 1.8.8.5 | Complete communications wiring - phone, cable, computer, alarm | 2d | 2009-06-08 | 2009-06-09 |  | 38d |  | start no earlier than 2009-06-06 | Electric contractor | 16h |
| 86 | 1.8.9 | **Landscaping and Grounds Work** | 3d | 2009-06-15 | 2009-06-17 |  | 32d |  |  |  | 24h |
| 87 | 1.8.9.1 | Sod and complete plantings - front yard | 2d | 2009-06-15 | 2009-06-16 |  | 32d | 0d | start no earlier than 2009-06-14 | Landscape contractor | 16h |
| 88 | 1.8.9.2 | Sod and complete plantings - backyard | 1d | 2009-06-17 | 2009-06-17 | 87 | 32d |  |  | Landscape contractor | 8h |
| 89 | 1.8.10 | **Final Acceptance** | 8d | 2009-06-30 | 2009-07-09 |  | 16d |  |  |  | 64h |
| 90 | 1.8.10.1 | Complete final inspection for certificate of occupancy | 1d | 2009-06-30 | 2009-06-30 |  | 16d | 0d | start no earlier than 2009-06-30 | Inspector | 8h |
| 91 | 1.8.10.2 | Cleanup for occupancy | 1d | 2009-07-01 | 2009-07-01 | 90 | 16d | 0d |  | Maid service | 8h |
| 92 | 1.8.10.3 | Perform final walk-through inspection | 1d | 2009-07-02 | 2009-07-02 | 91 | 16d | 0d |  | Owner | 8h |
| 93 | 1.8.10.4 | Complete punch list items | 5d | 2009-07-03 | 2009-07-09 | 92 | 16d |  |  | General contractor | 40h |
